# Target Hall Scheduled Activities,Apr 07-June 26 2015

Schedule from MS Project, 2015-04-07 to 2015-09-02, A marks actual dates.

## Calendars

- Standard: Mon-Fri 08:00-12:00, 13:00-17:00; Sat-Sun off.

## Resources

| Resource |
| --- |
| D.Wang |
| T.Cave |
| A.Mjos |
| C.Fisher |
| D.McDonald |
| RPG |
| ISAC Opps |
| M.Dalla Valle |
| K.Ng |
| G.Minor |
| D.Jackson |
| I.Earle |
| Vacuum Group |

## Schedule

| ID | WBS | Task | Duration | Start | Finish | Predecessors | Complete | Remaining | Total slack | Free slack | Constraint | Resources | Work | Actual work |
| --- | --- | --- | --- | --- | --- | --- | --- | --- | --- | --- | --- | --- | --- | --- |
| 1 | 1 | **TM4 Ta#45 ready for Beam at ITE** | 4d | 2015-04-07 08:00 A | 2015-04-10 17:00 A |  | 100% |  |  |  |  |  | 32h | 32h |
| 2 | 1.1 | Grounding Test-ITW, ITE | 1d | 2015-04-07 08:00 A | 2015-04-07 17:00 A |  | 100% |  |  |  |  | ISAC Opps | 8h | 8h |
| 3 | 1.2 | Foot Anchors Grout-ITW, ITE Handrails | 2.5d | 2015-04-08 08:00 A | 2015-04-10 12:00 A | 2 | 100% |  |  |  |  | M.Dalla Valle; D.McDonald; D.Wang | 20h | 20h |
| 4 | 1.3 | Shielding Blocks Move-ITW to ITE | 0.5d | 2015-04-10 13:00 A | 2015-04-10 17:00 A | 3 | 100% |  |  |  |  | D.Wang; D.McDonald | 4h | 4h |
| 5 | 2 | **TM1-TM2-TM4 Target Hall Activities** | 103d | 2015-04-13 08:00 A | 2015-09-02 17:00 |  | 66% | 34.58d | 0d |  |  |  | 1053.6h | 691.6h |
| 6 | 2.1 | **TM1 UCx Ready for Beam at ITW** | 8d | 2015-04-17 08:00 A | 2015-04-28 17:00 A |  | 100% |  |  |  |  |  | 85.6h | 85.6h |
| 7 | 2.1.1 | New Ucx Target in SHC/Cameras set up | 0.2d | 2015-04-17 08:00 A | 2015-04-17 09:36 A |  | 100% |  |  |  | start no earlier than 2015-04-17 08:00 | A.Mjos; I.Earle; T.Cave | 4.8h | 4.8h |
| 8 | 2.1.2 | Moduel Move-TM1-Silo to SHC | 0.2d | 2015-04-17 09:36 A | 2015-04-17 11:12 A | 7 | 100% |  |  |  | start no earlier than 2015-04-16 08:00 | T.Cave; D.Wang | 3.2h | 3.2h |
| 9 | 2.1.3 | Ucx target install /Leak , Electrical Check at SHC | 0.2d | 2015-04-17 11:12 A | 2015-04-17 13:48 A | 8 | 100% |  |  |  | start no earlier than 2015-04-16 08:00 | I.Earle; T.Cave; D.Wang | 4.8h | 4.8h |
| 10 | 2.1.4 | Module Move- TM1 -SHC to CS | 0.2d | 2015-04-17 13:48 A | 2015-04-17 15:24 A | 9 | 100% |  |  |  | start no earlier than 2015-04-16 08:00 | D.Wang; T.Cave | 3.2h | 3.2h |
| 11 | 2.1.5 | TM1 Vacuum Connect at CS/ CS Pump Down | 0.2d | 2015-04-17 15:24 A | 2015-04-17 17:00 A | 10 | 100% |  |  |  | start no earlier than 2015-04-16 08:00 | D.Wang | 1.6h | 1.6h |
| 12 | 2.1.6 | Heium Pressure Test-TM1 HS line at CS | 0.5d | 2015-04-20 08:00 A | 2015-04-20 12:00 A | 11 | 100% |  |  |  |  | D.Wang | 4h | 4h |
| 13 | 2.1.7 | TM1 Connect at CS/HV Cover Installed | 0.5d | 2015-04-20 13:00 A | 2015-04-20 17:00 A | 12 | 100% |  |  |  | start no earlier than 2015-04-17 08:00 | D.Wang; D.McDonald | 8h | 8h |
| 14 | 2.1.8 | Module Conditioning-TM1 at CS | 4.5d | 2015-04-21 08:00 A | 2015-04-27 12:00 A | 13 | 100% |  |  |  | start no earlier than 2015-04-20 08:00 | A.Mjos | 36h | 36h |
| 15 | 2.1.9 | Finish of Conditioning/Module Disconnect -TM1 at CS | 0.5d | 2015-04-27 13:00 A | 2015-04-27 17:00 A | 14 | 100% |  |  |  |  | D.Wang | 4h | 4h |
| 16 | 2.1.10 | Argon Vent CS /ITW cameras Set up/Shield Plug Move from ITW | 0.25d | 2015-04-28 08:00 A | 2015-04-28 10:00 A | 15 | 100% |  |  |  |  | D.Wang; T.Cave | 4h | 4h |
| 17 | 2.1.11 | Module Move -TM1-CS to ITW | 0.25d | 2015-04-28 10:00 A | 2015-04-28 12:00 A | 16 | 100% |  |  |  |  | D.Wang; T.Cave | 4h | 4h |
| 18 | 2.1.12 | Module Connect-TM1 at ITW/Start of Turbopumps | 0.5d | 2015-04-28 13:00 A | 2015-04-28 17:00 A | 17 | 100% |  |  |  |  | D.Wang; D.McDonald | 8h | 8h |
| 19 | 2.2 | **TM2 Refurbishment Completion** | 93d | 2015-04-13 08:00 A | 2015-08-19 17:00 |  | 63% | 34.19d | 10d |  |  |  | 540h | 356h |
| 20 | 2.2.1 | TM2 Top Service Cap Reconfiguration | 3d | 2015-04-13 08:00 A | 2015-04-15 17:00 A |  | 100% |  |  |  | finish no earlier than 2015-04-15 17:00 | D.Wang | 24h | 24h |
| 21 | 2.2.2 | Module Move -TM2-Silo to ITW | 1d | 2015-04-30 08:00 A | 2015-04-30 17:00 A |  | 100% |  |  |  | start no earlier than 2015-04-30 08:00 | T.Cave; D.Wang | 16h | 16h |
| 22 | 2.2.3 | TM2 Wiring Prepare/Work Area Set up in TH | 1d | 2015-05-01 08:00 A | 2015-05-01 17:00 A | 21 | 100% |  |  |  |  | D.Wang; T.Cave | 16h | 16h |
| 23 | 2.2.4 | TM2 Wiring - SHC & TM2 Service Cap | 2d | 2015-05-04 08:00 A | 2015-05-05 17:00 A | 22 | 100% |  |  |  |  | T.Cave; C.Fisher; D.Wang | 48h | 48h |
| 24 | 2.2.5 | Module Move-TM2-SHC to CS | 1d | 2015-05-27 08:00 A | 2015-05-27 17:00 A | 23 | 100% |  |  |  | start no earlier than 2015-05-27 08:00 | T.Cave; D.Wang | 16h | 16h |
| 25 | 2.2.6 | TM2 wiring-TM2 at CS | 1d | 2015-05-28 08:00 A | 2015-05-28 17:00 A | 24 | 100% |  |  |  | start no earlier than 2015-05-26 08:00 | T.Cave; D.Wang | 16h | 16h |
| 26 | 2.2.7 | Module move-TM2 -CS to Silo | 1d | 2015-05-29 08:00 A | 2015-05-29 17:00 A | 25 | 100% |  |  |  | start no earlier than 2015-05-28 08:00 | D.Wang; T.Cave | 16h | 16h |
| 27 | 2.2.8 | Source Tray Install on Transfer Table/Transfer Source Tray into SHC | 1d | 2015-06-11 08:00 A | 2015-06-11 17:00 A | 26 | 100% |  |  |  | start no earlier than 2015-06-11 08:00 | D.Wang; C.Fisher; T.Cave | 24h | 24h |
| 28 | 2.2.9 | Remove Transfer table-SHC to TH/Clean up | 0.5d | 2015-06-12 08:00 A | 2015-06-12 12:00 A | 27 | 100% |  |  |  | start no earlier than 2015-05-12 08:00 | C.Fisher; T.Cave; D.Wang | 12h | 12h |
| 29 | 2.2.10 | Module Move- TM2 -Silo to SHC | 1d | 2015-06-15 08:00 A | 2015-06-15 17:00 A |  | 100% |  |  |  | start no earlier than 2015-06-15 08:00 | T.Cave; D.Wang | 16h | 16h |
| 30 | 2.2.11 | Leak, Electrical Check-TM2 at SHC | 1d | 2015-06-24 08:00 A | 2015-06-24 17:00 A | 29 | 100% |  |  |  | start no earlier than 2015-06-22 08:00 | C.Fisher; T.Cave; D.Wang; D.Jackson | 32h | 32h |
| 31 | 2.2.12 | Module Move-TM2-SHC to CS/ Start of CS Pumps | 1d | 2015-06-26 08:00 A | 2015-06-26 17:00 A | 30 | 100% |  |  |  | start no earlier than 2015-06-26 08:00 | T.Cave; D.Wang | 16h | 16h |
| 32 | 2.2.13 | Helium Pressure Test -TM2 water lines at CS/TM2 Connnect at CS | 1d | 2015-06-29 08:00 A | 2015-06-29 17:00 A | 31 | 100% |  |  |  | start no earlier than 2015-06-24 08:00 | D.Wang | 8h | 8h |
| 33 | 2.2.14 | Module move-TM2- CS to SHC | 1d | 2015-07-03 10:00 A | 2015-07-06 10:00 A |  | 100% |  |  |  | finish no earlier than 2015-07-03 17:00 | D.Wang; T.Cave | 16h | 16h |
| 34 | 2.2.15 | Module Move-TM2-SHC to Silo | 0.5d | 2015-07-09 08:00 A | 2015-07-09 12:00 A |  | 100% |  |  |  | start no earlier than 2015-07-09 08:00 | D.Wang; T.Cave | 8h | 8h |
| 35 | 2.2.16 | Module Move-TM1 -Silo-CS/ Start roughing CS | 0.5d | 2015-07-09 13:00 A | 2015-07-09 17:00 A | 34 | 100% |  |  |  | start no earlier than 2015-07-09 08:00 | T.Cave; D.Wang | 8h | 8h |
| 36 | 2.2.17 | Start CS turbo-pumps /CS and TM 1 Pump down | 1d | 2015-07-10 08:00 A | 2015-07-10 17:00 A | 35 | 100% |  |  |  | start no earlier than 2015-07-10 08:00 | D.Wang | 8h | 8h |
| 37 | 2.2.18 | Module Move TM1- CS to Silo | 0.5d | 2015-07-13 08:00 A | 2015-07-13 12:00 A | 36 | 100% |  |  |  | start no earlier than 2015-07-13 08:00 | D.Wang; T.Cave | 8h | 8h |
| 38 | 2.2.19 | Dummy Target Insert into SHC | 0.5d | 2015-07-13 13:00 | 2015-07-13 17:00 | 37 |  |  | 37d |  | start no earlier than 2015-07-13 08:00 | C.Fisher; D.Wang; T.Cave | 12h |  |
| 39 | 2.2.20 | Module Move -TM2-Silo to SHC | 1d | 2015-07-14 08:00 A | 2015-07-14 17:00 A | 38 | 100% |  |  |  | start no earlier than 2015-07-14 08:00 | D.Wang; T.Cave | 16h | 16h |
| 40 | 2.2.21 | TM2 Coil Line Leak Check/Electrical Check | 1d | 2015-07-15 08:00 A | 2015-07-15 17:00 A |  | 100% |  |  |  | start no earlier than 2015-07-15 08:00 | C.Fisher; D.Wang; T.Cave | 24h | 24h |
| 41 | 2.2.22 | Module Move-TM2-SHC to Silo | 0.5d | 2015-07-24 08:00 A | 2015-07-24 12:00 A | 39 | 100% |  |  |  | start no earlier than 2015-07-24 08:00 | T.Cave; D.Wang | 8h | 8h |
| 42 | 2.2.23 | Module Move TM2- Silo to SHC | 0.5d | 2015-07-30 08:00 | 2015-07-30 12:00 |  |  |  | 24.5d |  | start no earlier than 2015-07-30 08:00 | D.Wang; T.Cave | 8h |  |
| 43 | 2.2.24 | Module Connect -TM2 at CS | 0.5d | 2015-08-04 08:00 | 2015-08-04 12:00 |  |  |  | 10.5d | 0.5d | start no earlier than 2015-08-04 08:00 | D.Wang | 4h |  |
| 44 | 2.2.25 | TM2 Condition at CS | 5d | 2015-08-05 08:00 | 2015-08-11 17:00 | 43 |  |  | 10d | 0d | finish no earlier than 2015-08-11 17:00 | ISAC Opps | 40h |  |
| 45 | 2.2.26 | TM2 Test at CS with Dummy Target | 4d | 2015-08-12 08:00 | 2015-08-17 17:00 | 44 |  |  | 10d | 0d | finish no earlier than 2015-08-17 17:00 | A.Mjos; D.Jackson; G.Minor | 96h |  |
| 46 | 2.2.27 | Finish of TM2 TEST /Module Disconnect-TM2 at CS | 1d | 2015-08-18 08:00 | 2015-08-18 17:00 | 45 |  |  | 10d | 0d | start no earlier than 2015-08-18 08:00 | D.Wang | 8h |  |
| 47 | 2.2.28 | Module Move TM2-CS to HC | 1d | 2015-08-19 08:00 | 2015-08-19 17:00 | 46 |  |  | 10d |  | start no earlier than 2015-08-19 08:00 | T.Cave; D.Wang | 16h |  |

| ID | WBS | Task | Duration | Start | Finish | Predecessors | Complete | Remaining | Total slack | Constraint | Resources | Work | Actual work |
| --- | --- | --- | --- | --- | --- | --- | --- | --- | --- | --- | --- | --- | --- |
| 48 | 2.3 | **TM4 HpSiC Ready for Beam at ITE** | 21d | 2015-05-22 08:00 A | 2015-06-19 17:00 A |  | 100% |  |  |  |  | 140h | 140h |
| 49 | 2.3.1 | Shielding Blocks Move-ITE to ITW | 1d | 2015-05-22 08:00 A | 2015-05-22 17:00 A | 18 | 100% |  |  | start no earlier than 2015-05-22 08:00 | D.Wang; D.McDonald | 16h | 16h |
| 50 | 2.3.2 | New HP SiC Target in SHC | 1d | 2015-06-01 08:00 A | 2015-06-01 17:00 A | 49 | 100% |  |  | start no earlier than 2015-06-01 08:00 | C.Fisher; A.Mjos | 16h | 16h |
| 51 | 2.3.3 | Cameras set up/Module Move-TM4 -ITE to SHC | 0.5d | 2015-06-02 08:00 A | 2015-06-02 12:00 A | 50 | 100% |  |  | start no earlier than 2015-06-02 08:00 | T.Cave; D.Wang | 8h | 8h |
| 52 | 2.3.4 | New SiC Target Install/Electrical,vacuum Check | 0.5d | 2015-06-02 13:00 A | 2015-06-02 17:00 A | 51 | 100% |  |  |  | C.Fisher; D.Wang; T.Cave | 12h | 12h |
| 53 | 2.3.5 | Module Move-TM4-SHC to CS/Start of CS Turbo Pumps | 1d | 2015-06-03 08:00 A | 2015-06-03 17:00 A | 52 | 100% |  |  |  | D.Wang; T.Cave | 16h | 16h |
| 54 | 2.3.6 | Spent Target Move -HPTa-SHC to Storage Vault | 0.5d | 2015-06-04 08:00 A | 2015-06-04 12:00 A | 53 | 100% |  |  |  | C.Fisher; T.Cave; D.Wang | 12h | 12h |
| 55 | 2.3.7 | Helium Pressure Test/Connect TM4 At CS/HV Cover on | 0.5d | 2015-06-04 08:00 A | 2015-06-04 12:00 A | 53 | 100% |  |  |  | D.Wang | 4h | 4h |
| 56 | 2.3.8 | Module Conditioning-TM4 at CS | 2.5d | 2015-06-04 13:00 A | 2015-06-08 17:00 A | 55 | 100% |  |  |  | A.Mjos | 20h | 20h |
| 57 | 2.3.9 | Finish of Conditioning/Module Disconnect -TM4 at CS | 0.5d | 2015-06-09 08:00 A | 2015-06-09 12:00 A | 56 | 100% |  |  |  | D.Wang | 4h | 4h |
| 58 | 2.3.10 | Module Move -TM4-CS to ITE | 0.5d | 2015-06-10 08:00 A | 2015-06-10 12:00 A | 57 | 100% |  |  | start no earlier than 2015-06-10 08:00 | T.Cave; D.Wang | 8h | 8h |
| 59 | 2.3.11 | Module Connect-TM4 at ITW/Start of ITE Turbopumps | 0.5d | 2015-06-10 13:00 A | 2015-06-10 17:00 A | 58 | 100% |  |  | start no earlier than 2015-06-10 08:00 | D.Wang; D.McDonald | 8h | 8h |
| 60 | 2.3.12 | Shielding Blocks Move-ITW to ITE/ ITE Ready for Proton Beam | 1d | 2015-06-19 08:00 A | 2015-06-19 17:00 A | 59 | 100% |  |  | start no earlier than 2015-06-19 08:00 | D.Wang; D.McDonald | 16h | 16h |
| 61 | 2.4 | **TM1 Phase out/TM2 First Run Start at ITW** | 47d | 2015-06-30 08:00 A | 2015-09-02 17:00 |  | 26% | 34.63d | 0d |  |  | 130h | 40h |
| 62 | 2.4.1 | Cameras Set up/Module Move-TM1 -ITW to SHC | 0.5d | 2015-06-30 08:00 A | 2015-06-30 12:00 A | 60 | 100% |  |  | start no earlier than 2015-06-30 08:00 | T.Cave; D.Wang; D.McDonald | 12h | 12h |
| 63 | 2.4.2 | Lp UCx Target Remove/ Electrical Check at SHC | 0.5d | 2015-06-30 13:00 A | 2015-06-30 17:00 A | 62 | 100% |  |  | start no earlier than 2015-06-30 08:00 | C.Fisher; T.Cave | 8h | 8h |
| 64 | 2.4.3 | Module Move- TM1 -SHC to Silo | 0.5d | 2015-07-02 08:00 A | 2015-07-02 12:00 A | 63 | 100% |  |  | start no earlier than 2015-07-02 08:00 | T.Cave; D.Wang | 8h | 8h |
| 65 | 2.4.4 | Spent Target Move -Lp UCx-SHC to Storage Vault | 0.5d | 2015-07-02 13:00 A | 2015-07-02 17:00 A | 64 | 100% |  |  | start no earlier than 2015-07-02 08:00 | C.Fisher; T.Cave; D.Wang | 12h | 12h |
| 66 | 2.4.5 | Shielding Blocks Move- ITE to Storage Area | 0.5d | 2015-07-24 08:00 A | 2015-07-24 12:00 A |  | 100% |  |  | start no earlier than 2015-07-24 08:00 |  |  |  |
| 67 | 2.4.6 | New Target in SHC for TM2 | 0.25d | 2015-08-25 08:00 | 2015-08-25 10:00 | 65 |  |  | 0d | start no earlier than 2015-08-25 08:00 | C.Fisher; A.Mjos | 4h |  |
| 68 | 2.4.7 | New Target Installation/ Electrical, Vacuum Check | 0.25d | 2015-08-25 10:00 | 2015-08-25 12:00 | 67 |  |  | 0d | start no earlier than 2015-08-25 08:00 | T.Cave; C.Fisher; D.Wang | 6h |  |
| 69 | 2.4.8 | Module Move -TM2-SHC to CS/Start of CS Pumps | 0.5d | 2015-08-25 13:00 | 2015-08-25 17:00 | 68 |  |  | 0d | start no earlier than 2015-07-07 08:00 | D.Wang; T.Cave | 8h |  |
| 70 | 2.4.9 | Module Connect-TM2 at ITW/Start of Turbo Pumps | 0.5d | 2015-08-26 08:00 | 2015-08-26 12:00 | 69 |  |  | 0d | start no earlier than 2015-08-26 08:00 | D.Wang; T.Cave | 8h |  |
| 71 | 2.4.10 | Helium Pressure Test/ Connect TM2 at CS | 0.5d | 2015-08-26 13:00 | 2015-08-26 17:00 | 70 |  |  | 0d | start no earlier than 2015-08-26 08:00 | D.Wang | 4h |  |
| 72 | 2.4.11 | TM2 Condition at CS | 3d | 2015-08-27 08:00 | 2015-08-31 17:00 | 71 |  |  | 0d | finish no earlier than 2015-08-31 17:00 | A.Mjos | 24h |  |
| 73 | 2.4.12 | Module Move TM2-CS to ITW | 0.5d | 2015-09-01 08:00 | 2015-09-01 12:00 | 72 |  |  | 0d | start no earlier than 2015-09-01 08:00 | T.Cave; D.Wang; D.McDonald | 12h |  |
| 74 | 2.4.13 | Module Connect-TM2 at ITW/Start of Turbo Pumps | 0.5d | 2015-09-01 13:00 | 2015-09-01 17:00 | 73 |  |  | 0d | start no earlier than 2015-09-01 08:00 | D.McDonald; D.Wang | 8h |  |
| 75 | 2.4.14 | Shielding Blocks Move- ITE to ITW/ ITW is Ready for Beam | 1d | 2015-09-02 08:00 | 2015-09-02 17:00 | 74 |  |  | 0d | start no earlier than 2015-09-02 08:00 | D.Wang; D.McDonald | 16h |  |

| ID | WBS | Task | Duration | Start | Finish | Predecessors | Complete | Remaining | Total slack | Free slack | Constraint | Resources | Work | Actual work |
| --- | --- | --- | --- | --- | --- | --- | --- | --- | --- | --- | --- | --- | --- | --- |
| 76 | 2.5 | **TM4 LpUcX Ready for Beam at ITE** | 10d | 2015-07-27 08:00 A | 2015-08-07 17:00 |  | 78% | 2.22d | 18d |  |  |  | 70h | 54h |
| 77 | 2.5.1 | Module Move-TM4-ITE to SHC | 0.25d | 2015-07-27 08:00 A | 2015-07-27 10:00 A | 66 | 100% |  |  |  | start no earlier than 2015-07-27 08:00 | D.Wang; T.Cave | 4h | 4h |
| 78 | 2.5.2 | Lp UcX Target Insert into SHC | 0.25d | 2015-07-27 10:00 A | 2015-07-27 12:00 A | 77 | 100% |  |  |  | start no earlier than 2015-07-27 08:00 | A.Mjos; C.Fisher | 4h | 4h |
| 79 | 2.5.3 | Target installation/Electrical, Vacuum check at SHC | 0.25d | 2015-07-27 13:00 A | 2015-07-27 15:00 A | 78 | 100% |  |  |  | start no earlier than 2015-07-27 08:00 | T.Cave; C.Fisher; D.Wang | 6h | 6h |
| 80 | 2.5.4 | Module Move-TM4-SHC to CS/ Start of Pumping | 0.25d | 2015-07-27 15:00 A | 2015-07-27 17:00 A | 79 | 100% |  |  |  | start no earlier than 2015-07-27 08:00 | D.Wang; T.Cave | 4h | 4h |
| 81 | 2.5.5 | Replace ITE TP4 in ITE Pit | 1d | 2015-07-28 08:00 A | 2015-07-28 17:00 A |  | 100% |  |  |  | start no earlier than 2015-07-28 08:00 | Vacuum Group | 8h | 8h |
| 82 | 2.5.6 | Module Move TM4- CS to ITE | 0.5d | 2015-07-29 08:00 A | 2015-07-29 12:00 A | 80 | 100% |  |  |  | start no earlier than 2015-07-29 08:00 | D.Wang; T.Cave | 8h | 8h |
| 83 | 2.5.7 | Module Connect-TM4 in ITE/Start of Turbo-Pumps | 0.5d | 2015-07-29 13:00 A | 2015-07-29 17:00 A | 82 | 100% |  |  |  | start no earlier than 2015-07-29 08:00 | D.Wang; D.McDonald | 8h | 8h |
| 84 | 2.5.8 | Spent target Move -Hp SiC -SHC to Storage Vault | 0.5d | 2015-07-30 08:00 A | 2015-07-30 12:00 A | 83 | 100% |  |  |  | start no earlier than 2015-07-30 08:00 | C.Fisher; D.Wang; T.Cave | 12h | 12h |
| 85 | 2.5.9 | Shielding Blocks Move-ITW to ITE/ ITE is Ready for Beam | 1d | 2015-08-07 08:00 | 2015-08-07 17:00 | 83 |  |  | 18d |  | start no earlier than 2015-08-07 08:00 | D.Wang; D.McDonald | 16h |  |
| 86 | 2.6 | **Spent Target Assay** | 7d | 2015-07-31 08:00 A | 2015-08-10 17:00 |  | 25% | 5.25d | 17d |  |  |  | 88h | 16h |
| 87 | 2.6.1 | Spent Target Assay Set up | 1d | 2015-07-31 08:00 A | 2015-07-31 17:00 A |  | 100% |  |  |  | start no earlier than 2015-07-31 08:00 | T.Cave; RPG | 16h | 16h |
| 88 | 2.6.2 | Spent Target Assay | 2d | 2015-08-05 08:00 | 2015-08-06 17:00 | 87 |  |  | 18d | 1d | start no earlier than 2015-08-05 08:00 | RPG; T.Cave; D.Wang | 48h |  |
| 89 | 2.6.3 | Spent Target Assay Continued | 1d | 2015-08-10 08:00 | 2015-08-10 17:00 | 88 |  |  | 17d |  | start no earlier than 2015-08-10 08:00 | RPG; T.Cave; D.Wang | 24h |  |
